# برنامه جدید کلینیک و آتش نشانی نهایی

Schedule from MS Project, 2009-04-20 to 2010-02-23, status date 2009-09-18, 10 hours a day, A marks actual dates.
Office07

## Calendars

- Standard: Mon-Sun 07:00-12:00, 13:00-18:00.

## Schedule

| ID | WBS | Task | Type | Duration | Start | Finish | Predecessors | Complete | Remaining | Baseline start | Baseline finish | Baseline duration | Total slack | Constraint | START SH | FINISH SH | Text1 | Text2 | Text3 |
| --- | --- | --- | --- | --- | --- | --- | --- | --- | --- | --- | --- | --- | --- | --- | --- | --- | --- | --- | --- |
| 1 | 1 | **Shadegan Steel making Plant Project** |  | 310d | 2009-04-20 A | 2010-02-23 |  | 37% | 195.85d | 2009-04-20 | 2009-12-29 | 254d | 0d |  | 88/1/31 | 88/12/4 |  |  |  |
| 2 | 1.1 | **احداث ساختمان های جنبی کلینیک و آتش نشانی** |  | 310d | 2009-04-20 A | 2010-02-23 |  | 37% | 195.85d | 2009-04-20 | 2009-12-29 | 254d | 0d |  | 88/1/31 | 88/12/4 | 100.00 | 87/11/30 | 88/11/06 |
| 3 | 1.1.1 | **ساختمان کلینیک** |  | 303d | 2009-04-20 A | 2010-02-16 |  | 39% | 184.23d | 2009-04-20 | 2009-12-06 | 231d | 7d |  | 88/1/31 | 88/11/27 | 50.00 | 87/12/01 | 88/10/29 |
| 4 | 1.1.1.1 | **عملیات اجرایی** |  | 303d | 2009-04-20 A | 2010-02-16 |  | 39% | 184.23d | 2009-04-20 | 2009-12-06 | 231d | 7d |  | 88/1/31 | 88/11/27 | 50.00 | 87/12/01 | 88/10/29 |
| 5 | 1.1.1.1.1 | **عملیات خاکی** |  | 0d | 2009-04-20 A | 2009-04-20 A |  | 100% |  | 2009-04-20 | 2009-04-20 | 0d |  |  | 88/1/31 | 88/1/31 |  |  |  |
| 6 | 1.1.1.1.1.1 | عملیات خاکی و بهسازی خاک | milestone | 0d | 2009-04-20 A | 2009-04-20 A |  | 100% |  | 2009-04-20 | 2009-04-20 | 0d |  | start no earlier than 2009-04-20 | 88/1/31 | 88/1/31 | 1.43 |  |  |
| 7 | 1.1.1.1.1.2 | تسطیح کف و رگلاژ | milestone | 0d | 2009-04-20 A | 2009-04-20 A | 6 | 100% |  | 2009-04-20 | 2009-04-20 | 0d |  |  | 88/1/31 | 88/1/31 | 0.07 |  |  |
| 8 | 1.1.1.1.2 | **اجرای فونداسیون** |  | 35d | 2009-04-21 A | 2009-05-25 A |  | 100% |  | 2009-04-21 | 2009-05-25 | 35d |  |  | 88/2/1 | 88/3/4 | 3.50 | 87/12/01 | 88/02/18 |
| 9 | 1.1.1.1.2.1 | بتن مگر |  | 2d | 2009-04-21 A | 2009-04-22 A | 7FS+1d | 100% |  | 2009-04-21 | 2009-04-22 | 2d |  |  | 88/2/1 | 88/2/2 | 0.18 | 87/12/01 | 87/12/03 |
| 10 | 1.1.1.1.2.2 | آرماتور بندی فوتینگ |  | 7d | 2009-04-23 A | 2009-04-29 A | 9 | 100% |  | 2009-04-23 | 2009-04-29 | 7d |  |  | 88/2/3 | 88/2/9 | 0.34 | 87/12/01 | 87/12/15 |
| 11 | 1.1.1.1.2.3 | قالب بندی فوتینگ |  | 7d | 2009-04-30 A | 2009-05-06 A | 10 | 100% |  | 2009-04-30 | 2009-05-06 | 7d |  |  | 88/2/10 | 88/2/16 | 0.35 | 87/12/16 | 87/12/30 |
| 12 | 1.1.1.1.2.4 | بتن ریزی فوتینگ |  | 4d | 2009-05-07 A | 2009-05-10 A | 11 | 100% |  | 2009-05-07 | 2009-05-10 | 4d |  |  | 88/2/17 | 88/2/20 | 0.52 | 88/01/01 | 88/01/10 |
| 13 | 1.1.1.1.2.5 | آرماتور بندی پدستال |  | 3d | 2009-05-11 A | 2009-05-13 A | 12 | 100% |  | 2009-05-11 | 2009-05-13 | 3d |  | finish no earlier than 2009-04-21 | 88/2/21 | 88/2/23 | 0.35 | 88/01/11 | 88/01/16 |
| 14 | 1.1.1.1.2.6 | قالب بندی پدستال |  | 3d | 2009-05-11 A | 2009-05-13 A | 12 | 100% |  | 2009-05-11 | 2009-05-13 | 3d |  |  | 88/2/21 | 88/2/23 | 0.35 | 88/01/12 | 88/01/17 |
| 15 | 1.1.1.1.2.7 | نصب انکر بولت و بیس پلیت |  | 3d | 2009-05-14 A | 2009-05-16 A | 14 | 100% |  | 2009-05-14 | 2009-05-16 | 3d |  |  | 88/2/24 | 88/2/26 | 0.52 | 88/01/18 | 88/01/24 |
| 16 | 1.1.1.1.2.8 | بتن ریزی پدستال |  | 3d | 2009-05-17 A | 2009-05-19 A | 15 | 100% |  | 2009-05-17 | 2009-05-19 | 3d |  |  | 88/2/27 | 88/2/29 | 0.53 | 88/01/25 | 88/01/28 |
| 17 | 1.1.1.1.2.9 | کیورینگ |  | 3d | 2009-05-20 A | 2009-05-22 A | 16 | 100% |  | 2009-05-20 | 2009-05-22 | 3d |  |  | 88/2/30 | 88/3/1 | 0.18 | 88/01/29 | 88/02/04 |
| 18 | 1.1.1.1.2.10 | درناژ |  | 3d | 2009-05-23 A | 2009-05-25 A | 17 | 100% |  | 2009-05-23 | 2009-05-25 | 3d |  |  | 88/3/2 | 88/3/4 | 0.18 | 88/02/05 | 88/02/18 |
| 19 | 1.1.1.1.3 | **ساخت و نصب اسکلت فلزی** |  | 65d | 2009-05-09 A | 2009-07-12 A |  | 100% |  | 2009-05-09 | 2009-07-12 | 65d |  |  | 88/2/19 | 88/4/21 | 9.50 | 87/12/23 | 88/03/21 |
| 20 | 1.1.1.1.3.1 | ساخت قطعات اسکلت فلزی |  | 64d | 2009-05-09 A | 2009-07-11 A |  | 100% |  | 2009-05-09 | 2009-07-11 | 64d |  | start no earlier than 2009-05-09 | 88/2/19 | 88/4/20 | 3.80 | 87/12/23 | 88/03/20 |
| 21 | 1.1.1.1.3.2 | رنگ آمیزی قطعات اسکلت فلزی |  | 36d | 2009-06-06 A | 2009-07-11 A | 20FF | 100% |  | 2009-06-06 | 2009-07-11 | 36d |  |  | 88/3/16 | 88/4/20 | 0.95 | 88/02/16 | 88/03/20 |
| 22 | 1.1.1.1.3.3 | نصب قطعات اسکلت فلزی |  | 36d | 2009-06-07 A | 2009-07-12 A | 21FF+1d | 100% |  | 2009-06-07 | 2009-07-12 | 36d |  |  | 88/3/17 | 88/4/21 | 4.75 | 88/02/17 | 88/03/21 |
| 23 | 1.1.1.1.4 | **اجرای سقف** |  | 85d | 2009-07-13 A | 2009-10-05 |  | 87% | 11.02d | 2009-07-13 | 2009-08-09 | 28d | 141d |  | 88/4/22 | 88/7/13 | 4.50 | 88/03/22 | 88/05/12 |
| 24 | 1.1.1.1.4.1 | نصب تیرچه |  | 20d | 2009-07-13 A | 2009-08-01 A | 22 | 100% |  | 2009-07-13 | 2009-08-01 | 20d |  |  | 88/4/22 | 88/5/10 | 1.13 | 88/03/22 | 88/04/25 |
| 25 | 1.1.1.1.4.2 | نصب بلوک |  | 20d | 2009-07-13 A | 2009-08-01 A | 22 | 100% |  | 2009-07-13 | 2009-08-01 | 20d |  |  | 88/4/22 | 88/5/10 | 1.13 | 88/03/22 | 88/04/25 |
| 26 | 1.1.1.1.4.3 | بتن سقف |  | 7d | 2009-07-27 A | 2009-08-02 A | 25FS-6d | 100% |  | 2009-07-27 | 2009-08-02 | 7d |  |  | 88/5/5 | 88/5/11 | 1.79 | 88/04/20 | 88/04/29 |
| 27 | 1.1.1.1.4.4 | ساخت جان پناه و اجرای کامل بام |  | 7d | 2009-09-29 | 2009-10-05 | 26FS+57d |  |  | 2009-08-03 | 2009-08-09 | 7d | 141d |  | 88/7/7 | 88/7/13 | 0.45 | 88/04/30 | 88/05/12 |

| ID | WBS | Task | Duration | Start | Finish | Predecessors | Complete | Remaining | Baseline start | Baseline finish | Baseline duration | Total slack | Free slack | Text1 | Text2 | Text3 | START SH | FINISH SH |
| --- | --- | --- | --- | --- | --- | --- | --- | --- | --- | --- | --- | --- | --- | --- | --- | --- | --- | --- |
| 28 | 1.1.1.1.5 | **عملیات سفت کاری** | 53d | 2009-08-22 A | 2009-10-13 |  | 13% | 45.93d | 2009-07-06 | 2009-08-02 | 28d | 133d |  | 4.50 | 88/05/13 | 88/06/28 | 88/5/31 | 88/7/21 |
| 29 | 1.1.1.1.5.1 | کرسی چینی | 4d | 2009-08-22 A | 2009-08-25 A | 22FS+40d | 100% |  | 2009-07-06 | 2009-07-09 | 4d |  |  | 0.55 | 88/05/13 | 88/05/17 | 88/5/31 | 88/6/3 |
| 30 | 1.1.1.1.5.2 | عایق کاری | 4d | 2009-09-20 | 2009-09-23 | 29FS+25d |  |  | 2009-07-10 | 2009-07-13 | 4d | 7d | 0d | 0.56 | 88/05/18 | 88/05/22 | 88/6/29 | 88/7/1 |
| 31 | 1.1.1.1.5.3 | سنگ ازاره | 4d | 2009-09-24 | 2009-09-27 | 30 |  |  | 2009-07-14 | 2009-07-17 | 4d | 7d | 0d | 1.13 | 88/05/23 | 88/05/26 | 88/7/2 | 88/7/5 |
| 32 | 1.1.1.1.5.4 | دیوار چینی | 14d | 2009-09-28 | 2009-10-11 | 31 |  |  | 2009-07-18 | 2009-07-31 | 14d | 133d | 0d | 1.13 | 88/05/27 | 88/06/25 | 88/7/6 | 88/7/19 |
| 33 | 1.1.1.1.5.5 | فرم درب و پنجره ها و هندریل | 4d | 2009-10-10 | 2009-10-13 | 32FS-2d |  |  | 2009-07-30 | 2009-08-02 | 4d | 133d |  | 1.13 | 88/06/24 | 88/06/28 | 88/7/18 | 88/7/21 |
| 34 | 1.1.1.1.6 | **کف سازی** | 76d | 2009-09-19 | 2009-12-03 |  |  |  | 2009-08-03 | 2009-09-22 | 51d | 75d |  | 2.50 | 88/06/29 | 88/09/22 | 88/6/28 | 88/9/12 |
| 35 | 1.1.1.1.6.1 | بلوکاژ و شن ریزی | 12d | 2009-09-19 | 2009-09-30 | 29SS+28d |  |  | 2009-08-03 | 2009-08-14 | 12d | 124d | 0d | 0.21 | 88/06/29 | 88/07/09 | 88/6/28 | 88/7/8 |
| 36 | 1.1.1.1.6.2 | آبپاشی و ماسه ریزی | 4d | 2009-10-08 | 2009-10-11 | 35FS+7d |  |  | 2009-08-15 | 2009-08-18 | 4d | 124d | 0d | 0.21 | 88/07/10 | 88/07/13 | 88/7/16 | 88/7/19 |
| 37 | 1.1.1.1.6.3 | بتن کف | 4d | 2009-10-12 | 2009-10-15 | 36 |  |  | 2009-08-19 | 2009-08-22 | 4d | 124d | 0d | 1.25 | 88/07/14 | 88/07/17 | 88/7/20 | 88/7/23 |
| 38 | 1.1.1.1.6.4 | سنگ و سرامیک کف | 26d | 2009-11-08 | 2009-12-03 | 53FF-7d |  |  | 2009-08-28 | 2009-09-22 | 26d | 75d | 0d | 0.83 | 88/08/27 | 88/09/22 | 88/8/17 | 88/9/12 |
| 39 | 1.1.1.1.7 | **مرحله اول عملیات نازک کاری** | 27d | 2009-10-18 | 2009-11-13 |  |  |  | 2009-08-07 | 2009-09-02 | 27d | 7d |  | 4.00 | 88/05/27 | 88/08/14 | 88/7/26 | 88/8/22 |
| 40 | 1.1.1.1.7.1 | سنگ ازاره | 7d | 2009-10-18 | 2009-10-24 | 31FS+20d |  |  | 2009-08-07 | 2009-08-13 | 7d | 7d | 0d | 0.39 | 88/05/27 | 88/05/31 | 88/7/26 | 88/8/2 |
| 41 | 1.1.1.1.7.2 | (پلاستر داخلی (سیمانکاری | 10d | 2009-10-18 | 2009-10-27 | 40SS |  |  | 2009-08-07 | 2009-08-16 | 10d | 7d | 0d | 1.21 | 88/06/24 | 88/07/07 | 88/7/26 | 88/8/5 |
| 42 | 1.1.1.1.7.3 | اجرای سقف کاذب | 20d | 2009-10-25 | 2009-11-13 | 41FS-3d |  |  | 2009-08-14 | 2009-09-02 | 20d | 7d | 0d | 2.40 | 88/07/05 | 88/08/14 | 88/8/3 | 88/8/22 |
| 43 | 1.1.1.1.8 | **مرحله اول تأسیسات** | 30d | 2009-11-02 | 2009-12-01 |  |  |  | 2009-08-22 | 2009-09-20 | 30d | 7d |  | 5.00 | 88/07/05 | 88/08/14 | 88/8/11 | 88/9/10 |
| 44 | 1.1.1.1.8.1 | لوله کشی آب | 25d | 2009-11-02 | 2009-11-26 | 42SS+8d |  |  | 2009-08-22 | 2009-09-15 | 25d | 7d | 0d | 0.74 | 88/07/05 | 88/08/14 | 88/8/11 | 88/9/5 |
| 45 | 1.1.1.1.8.2 | فاضلاب و برق | 25d | 2009-11-05 | 2009-11-29 | 44SS+3d |  |  | 2009-08-25 | 2009-09-18 | 25d | 7d | 0d | 1.50 | 88/07/05 | 88/08/14 | 88/8/14 | 88/9/8 |
| 46 | 1.1.1.1.8.3 | نصب ساپورت های تأسیسات | 24d | 2009-11-08 | 2009-12-01 | 45SS+3d |  |  | 2009-08-28 | 2009-09-20 | 24d | 7d | 0d | 2.76 | 88/07/05 | 88/08/14 | 88/8/17 | 88/9/10 |
| 47 | 1.1.1.1.9 | **نمای ساختمان** | 28d | 2009-11-25 | 2009-12-22 |  |  |  | 2009-09-14 | 2009-10-11 | 28d | 7d |  | 3.00 | 88/08/15 | 88/10/29 | 88/9/4 | 88/10/1 |
| 48 | 1.1.1.1.9.1 | سنگ و آجر نما و بندکشی ها | 11d | 2009-11-25 | 2009-12-05 | 46FS-7d |  |  | 2009-09-14 | 2009-09-24 | 11d | 7d | 0d | 1.50 | 88/08/15 | 88/09/14 | 88/9/4 | 88/9/14 |
| 49 | 1.1.1.1.9.2 | سیمانکاری و رویه نما | 10d | 2009-12-06 | 2009-12-15 | 48 |  |  | 2009-09-25 | 2009-10-04 | 10d | 7d | 0d | 0.90 | 88/08/15 | 88/08/29 | 88/9/15 | 88/9/24 |
| 50 | 1.1.1.1.9.3 | نصب شیشه | 7d | 2009-12-16 | 2009-12-22 | 49 |  |  | 2009-10-05 | 2009-10-11 | 7d | 7d | 0d | 0.60 | 88/10/23 | 88/10/29 | 88/9/25 | 88/10/1 |
| 51 | 1.1.1.1.10 | **مرحله دوم نازک کاری** | 27d | 2009-11-14 | 2009-12-10 |  |  |  | 2009-09-03 | 2009-09-29 | 27d | 47d |  | 4.00 | 88/08/15 | 88/09/29 | 88/8/23 | 88/9/19 |
| 52 | 1.1.1.1.10.1 | نصب درب و پنجره ها | 18d | 2009-11-14 | 2009-12-01 | 42 |  |  | 2009-09-03 | 2009-09-20 | 18d | 47d | 0d | 0.86 | 88/08/15 | 88/09/14 | 88/8/23 | 88/9/10 |
| 53 | 1.1.1.1.10.2 | گچ و خاک و سفید کاری | 9d | 2009-12-02 | 2009-12-10 | 52 |  |  | 2009-09-21 | 2009-09-29 | 9d | 47d | 0d | 2.64 | 88/09/15 | 88/09/29 | 88/9/11 | 88/9/19 |
| 54 | 1.1.1.1.10.3 | کاشی و سرامیک سرویس ها | 9d | 2009-12-02 | 2009-12-10 | 52 |  |  | 2009-09-21 | 2009-09-29 | 9d | 75d |  | 0.50 | 88/09/15 | 88/09/29 | 88/9/11 | 88/9/19 |

| ID | WBS | Task | Type | Duration | Start | Finish | Predecessors | Complete | Remaining | Baseline start | Baseline finish | Baseline duration | Total slack | Free slack | Constraint | Text1 | Text2 | Text3 | START SH | FINISH SH |
| --- | --- | --- | --- | --- | --- | --- | --- | --- | --- | --- | --- | --- | --- | --- | --- | --- | --- | --- | --- | --- |
| 55 | 1.1.1.1.11 | **مرحله دوم تأسیسات** |  | 30d | 2009-12-21 | 2010-01-19 |  |  |  | 2009-10-10 | 2009-11-08 | 30d | 7d |  |  | 6.50 | 88/08/18 | 88/10/05 | 88/9/30 | 88/10/29 |
| 56 | 1.1.1.1.11.1 | نصب دریچه و تجهیزات هواساز |  | 10d | 2009-12-23 | 2010-01-01 | 50 |  |  | 2009-10-12 | 2009-10-21 | 10d | 7d | 0d |  | 1.30 | 88/08/18 | 88/09/05 | 88/10/2 | 88/10/11 |
| 57 | 1.1.1.1.11.2 | نصب تابلوهای برق |  | 10d | 2009-12-23 | 2010-01-01 | 56SS |  |  | 2009-10-12 | 2009-10-21 | 10d | 7d | 0d |  | 1.30 | 88/08/18 | 88/09/09 | 88/10/2 | 88/10/11 |
| 58 | 1.1.1.1.11.3 | سیم کشی |  | 12d | 2009-12-21 | 2010-01-01 | 57FF |  |  | 2009-10-10 | 2009-10-21 | 12d | 7d | 0d |  | 0.97 | 88/08/25 | 88/09/09 | 88/9/30 | 88/10/11 |
| 59 | 1.1.1.1.11.4 | نصب کلید و پریز |  | 7d | 2010-01-02 | 2010-01-08 | 58 |  |  | 2009-10-22 | 2009-10-28 | 7d | 46d |  |  | 0.97 | 88/09/10 | 88/09/18 | 88/10/12 | 88/10/18 |
| 60 | 1.1.1.1.11.5 | روشنایی |  | 10d | 2010-01-02 | 2010-01-11 | 58 |  |  | 2009-10-22 | 2009-10-31 | 10d | 43d |  |  | 0.98 | 88/09/10 | 88/09/21 | 88/10/12 | 88/10/21 |
| 61 | 1.1.1.1.11.6 | سرویس بهداشتی |  | 18d | 2010-01-02 | 2010-01-19 | 58 |  |  | 2009-10-22 | 2009-11-08 | 18d | 7d | 0d |  | 0.98 | 88/09/10 | 88/10/05 | 88/10/12 | 88/10/29 |
| 62 | 1.1.1.1.12 | **رنگ آمیزی** |  | 28d | 2010-01-20 | 2010-02-16 | 53 |  |  | 2009-11-09 | 2009-12-06 | 28d | 7d | 0d |  | 1.50 | 88/09/30 | 88/10/29 | 88/10/30 | 88/11/27 |
| 63 | 1.1.1.1.12.1 | رنگ آمیزی ساختمان كلينيك |  | 28d | 2010-01-20 | 2010-02-16 | 61 |  |  | 2009-11-09 | 2009-12-06 | 28d | 7d |  |  | 1.50 |  |  | 88/10/30 | 88/11/27 |
| 64 | 1.1.2 | **ساختمان آتش نشانی** |  | 310d | 2009-04-20 A | 2010-02-23 |  | 34% | 203.56d | 2009-04-20 | 2009-12-29 | 254d | 0d |  |  | 50.00 | 87/12/08 | 88/11/06 | 88/1/31 | 88/12/4 |
| 65 | 1.1.2.1 | **عملیات اجرایی** |  | 310d | 2009-04-20 A | 2010-02-23 |  | 34% | 203.56d | 2009-04-20 | 2009-12-29 | 254d | 0d |  |  | 50.00 | 87/12/08 | 88/11/06 | 88/1/31 | 88/12/4 |
| 66 | 1.1.2.1.1 | **عملیات خاکی** |  | 0d | 2009-04-20 A | 2009-04-20 A |  | 100% |  | 2009-04-20 | 2009-04-20 | 0d |  |  |  |  |  |  | 88/1/31 | 88/1/31 |
| 67 | 1.1.2.1.1.1 | عملیات خاکی و بهسازی خاک | milestone | 0d | 2009-04-20 A | 2009-04-20 A | 6SS | 100% |  | 2009-04-20 | 2009-04-20 | 0d |  |  |  | 1.43 |  |  | 88/1/31 | 88/1/31 |
| 68 | 1.1.2.1.1.2 | تسطیح کف و رگلاژ | milestone | 0d | 2009-04-20 A | 2009-04-20 A | 6 | 100% |  | 2009-04-20 | 2009-04-20 | 0d |  |  |  | 0.07 |  |  | 88/1/31 | 88/1/31 |
| 69 | 1.1.2.1.2 | **اجرای فونداسیون** |  | 35d | 2009-04-20 A | 2009-05-24 A |  | 100% |  | 2009-04-20 | 2009-05-24 | 35d |  |  |  | 3.50 | 87/12/08 | 88/02/25 | 88/1/31 | 88/3/3 |
| 70 | 1.1.2.1.2.1 | بتن مگر |  | 2d | 2009-04-20 A | 2009-04-21 A | 68 | 100% |  | 2009-04-20 | 2009-04-21 | 2d |  |  | start no earlier than 2009-02-09 | 0.18 | 87/12/08 | 87/12/10 | 88/1/31 | 88/2/1 |
| 71 | 1.1.2.1.2.2 | آرماتور بندی فوتینگ |  | 7d | 2009-04-22 A | 2009-04-28 A | 70 | 100% |  | 2009-04-22 | 2009-04-28 | 7d |  |  |  | 0.35 | 87/12/08 | 87/12/22 | 88/2/2 | 88/2/8 |
| 72 | 1.1.2.1.2.3 | قالب بندی فوتینگ |  | 7d | 2009-04-29 A | 2009-05-05 A | 71 | 100% |  | 2009-04-29 | 2009-05-05 | 7d |  |  |  | 0.35 | 87/12/23 | 88/01/07 | 88/2/9 | 88/2/15 |
| 73 | 1.1.2.1.2.4 | بتن ریزی فوتینگ |  | 3d | 2009-05-06 A | 2009-05-08 A | 72 | 100% |  | 2009-05-06 | 2009-05-08 | 3d |  |  |  | 0.52 | 88/01/08 | 88/01/17 | 88/2/16 | 88/2/18 |
| 74 | 1.1.2.1.2.5 | آرماتور بندی پدستال |  | 3d | 2009-05-09 A | 2009-05-11 A | 73 | 100% |  | 2009-05-09 | 2009-05-11 | 3d |  |  |  | 0.35 | 88/01/18 | 88/01/23 | 88/2/19 | 88/2/21 |
| 75 | 1.1.2.1.2.6 | قالب بندی پدستال |  | 3d | 2009-05-12 A | 2009-05-14 A | 74 | 100% |  | 2009-05-12 | 2009-05-14 | 3d |  |  |  | 0.35 | 88/01/19 | 88/01/24 | 88/2/22 | 88/2/24 |
| 76 | 1.1.2.1.2.7 | نصب انکر بولت و بیس پلیت |  | 3d | 2009-05-15 A | 2009-05-17 A | 75 | 100% |  | 2009-05-15 | 2009-05-17 | 3d |  |  |  | 0.52 | 88/01/25 | 88/01/31 | 88/2/25 | 88/2/27 |
| 77 | 1.1.2.1.2.8 | بتن ریزی پدستال |  | 3d | 2009-05-18 A | 2009-05-20 A | 76 | 100% |  | 2009-05-18 | 2009-05-20 | 3d |  |  |  | 0.52 | 88/02/01 | 88/02/04 | 88/2/28 | 88/2/30 |
| 78 | 1.1.2.1.2.9 | کیورینگ |  | 2d | 2009-05-21 A | 2009-05-22 A | 77 | 100% |  | 2009-05-21 | 2009-05-22 | 2d |  |  |  | 0.18 | 88/02/05 | 88/02/11 | 88/2/31 | 88/3/1 |
| 79 | 1.1.2.1.2.10 | درناژ |  | 2d | 2009-05-23 A | 2009-05-24 A | 78 | 100% |  | 2009-05-23 | 2009-05-24 | 2d |  |  |  | 0.18 | 88/02/12 | 88/02/25 | 88/3/2 | 88/3/3 |

| ID | WBS | Task | Duration | Start | Finish | Predecessors | Complete | Remaining | Baseline start | Baseline finish | Baseline duration | Total slack | Free slack | Text1 | Text2 | Text3 | START SH | FINISH SH |
| --- | --- | --- | --- | --- | --- | --- | --- | --- | --- | --- | --- | --- | --- | --- | --- | --- | --- | --- |
| 80 | 1.1.2.1.3 | **ساخت و نصب اسکلت فلزی** | 65d | 2009-05-09 A | 2009-07-12 A |  | 100% |  | 2009-05-09 | 2009-07-12 | 65d |  |  | 9.50 | 87/12/30 | 88/03/28 | 88/2/19 | 88/4/21 |
| 81 | 1.1.2.1.3.1 | ساخت قطعات اسکلت فلزی | 64d | 2009-05-09 A | 2009-07-11 A | 20SS | 100% |  | 2009-05-09 | 2009-07-11 | 64d |  |  | 3.80 | 87/12/30 | 88/03/27 | 88/2/19 | 88/4/20 |
| 82 | 1.1.2.1.3.2 | رنگ آمیزی قطعات اسکلت فلزی | 36d | 2009-06-06 A | 2009-07-11 A | 21SS | 100% |  | 2009-06-06 | 2009-07-11 | 36d |  |  | 0.95 | 88/02/23 | 88/03/27 | 88/3/16 | 88/4/20 |
| 83 | 1.1.2.1.3.3 | نصب قطعات اسکلت فلزی | 36d | 2009-06-07 A | 2009-07-12 A | 22SS | 100% |  | 2009-06-07 | 2009-07-12 | 36d |  |  | 4.75 | 88/02/17 | 88/03/28 | 88/3/17 | 88/4/21 |
| 84 | 1.1.2.1.4 | **اجرای سقف** | 22d | 2009-09-11 A | 2009-10-02 |  | 28% | 15.77d | 2009-07-13 | 2009-08-09 | 28d | 144d |  | 4.50 | 88/03/29 | 88/05/19 | 88/6/20 | 88/7/10 |
| 85 | 1.1.2.1.4.1 | نصب تیرچه | 20d | 2009-09-11 A | 2009-09-30 | 24SS+60d | 36% | 12.9d | 2009-07-13 | 2009-08-01 | 20d | 146d | 0d | 1.13 | 88/03/29 | 88/05/01 | 88/6/20 | 88/7/8 |
| 86 | 1.1.2.1.4.2 | نصب بلوک | 20d | 2009-09-13 A | 2009-10-02 | 85SS+2d | 26% | 14.9d | 2009-07-13 | 2009-08-01 | 20d | 144d |  | 1.12 | 88/03/29 | 88/05/01 | 88/6/22 | 88/7/10 |
| 87 | 1.1.2.1.4.3 | بتن سقف | 7d | 2009-09-15 A | 2009-09-21 | 85SS+4d | 44% | 3.9d | 2009-07-27 | 2009-08-02 | 7d | 148d | 0d | 1.80 | 88/04/27 | 88/05/05 | 88/6/24 | 88/6/30 |
| 88 | 1.1.2.1.4.4 | ساخت جان پناه و اجرای کامل بام | 7d | 2009-09-22 | 2009-09-28 | 87 |  |  | 2009-08-03 | 2009-08-09 | 7d | 148d |  | 0.45 | 88/05/30 | 88/05/19 | 88/6/31 | 88/7/6 |
| 89 | 1.1.2.1.5 | **عملیات سفت کاری** | 26d | 2009-09-16 A | 2009-10-11 |  | 8% | 23.96d | 2009-08-07 | 2009-09-03 | 28d | 135d |  | 4.50 | 88/05/20 | 88/07/04 | 88/6/25 | 88/7/19 |
| 90 | 1.1.2.1.5.1 | کرسی چینی | 4d | 2009-09-16 A | 2009-09-19 | 87FS-6d | 53% | 1.9d | 2009-08-07 | 2009-08-10 | 4d | 157d | 0d | 0.56 | 88/05/20 | 88/05/24 | 88/6/25 | 88/6/28 |
| 91 | 1.1.2.1.5.2 | عایق کاری | 4d | 2009-09-18 A | 2009-09-21 | 90SS+2d | 3% | 3.9d | 2009-08-11 | 2009-08-14 | 4d | 18d | 0d | 0.56 | 88/05/25 | 88/05/29 | 88/6/27 | 88/6/30 |
| 92 | 1.1.2.1.5.3 | سنگ ازاره | 4d | 2009-09-22 | 2009-09-25 | 91 |  |  | 2009-08-15 | 2009-08-18 | 4d | 18d | 0d | 1.14 | 88/05/30 | 88/06/02 | 88/6/31 | 88/7/3 |
| 93 | 1.1.2.1.5.4 | دیوار چینی | 12d | 2009-09-26 | 2009-10-07 | 92 |  |  | 2009-08-19 | 2009-08-30 | 12d | 18d | 0d | 1.12 | 88/06/03 | 88/07/01 | 88/7/4 | 88/7/15 |
| 94 | 1.1.2.1.5.5 | فرم درب و پنجره ها و هندریل | 4d | 2009-10-08 | 2009-10-11 | 93 |  |  | 2009-08-31 | 2009-09-03 | 4d | 18d | 0d | 1.12 | 88/06/31 | 88/07/04 | 88/7/16 | 88/7/19 |
| 95 | 1.1.2.1.6 | **کف سازی** | 81d | 2009-09-21 | 2009-12-10 |  |  |  | 2009-08-10 | 2009-09-29 | 51d | 75d |  | 2.50 | 88/07/05 | 88/09/29 | 88/6/30 | 88/9/19 |
| 96 | 1.1.2.1.6.1 | بلوکاژ و شن ریزی | 12d | 2009-09-21 | 2009-10-02 | 35SS+2d |  |  | 2009-08-10 | 2009-08-21 | 12d | 144d |  | 0.21 | 88/07/05 | 88/07/16 | 88/6/30 | 88/7/10 |
| 97 | 1.1.2.1.6.2 | آبپاشی و ماسه ریزی | 4d | 2009-10-15 | 2009-10-18 | 36SS+7d |  |  | 2009-08-22 | 2009-08-25 | 4d | 128d |  | 0.21 | 88/07/17 | 88/07/20 | 88/7/23 | 88/7/26 |
| 98 | 1.1.2.1.6.3 | بتن کف | 4d | 2009-10-19 | 2009-10-22 | 37SS+7d |  |  | 2009-08-26 | 2009-08-29 | 4d | 124d |  | 1.25 | 88/07/21 | 88/07/24 | 88/7/27 | 88/7/30 |
| 99 | 1.1.2.1.6.4 | سنگ و سرامیک کف | 26d | 2009-11-15 | 2009-12-10 | 38SS+7d |  |  | 2009-09-04 | 2009-09-29 | 26d | 75d |  | 0.83 | 88/09/04 | 88/09/29 | 88/8/24 | 88/9/19 |
| 100 | 1.1.2.1.7 | **مرحله اول عملیات نازک کاری** | 26d | 2009-10-09 | 2009-11-03 |  |  |  | 2009-09-01 | 2009-09-26 | 26d | 18d |  | 4.00 | 88/06/03 | 88/08/21 | 88/7/17 | 88/8/12 |
| 101 | 1.1.2.1.7.1 | سنگ ازاره | 7d | 2009-10-09 | 2009-10-15 | 94FS-3d |  |  | 2009-09-01 | 2009-09-07 | 7d | 18d | 0d | 0.39 | 88/06/03 | 88/06/07 | 88/7/17 | 88/7/23 |
| 102 | 1.1.2.1.7.2 | (پلاستر داخلی (سیمانکاری | 10d | 2009-10-09 | 2009-10-18 | 101SS |  |  | 2009-09-01 | 2009-09-10 | 10d | 18d | 0d | 1.21 | 88/06/31 | 88/07/14 | 88/7/17 | 88/7/26 |
| 103 | 1.1.2.1.7.3 | اجرای سقف کاذب | 20d | 2009-10-15 | 2009-11-03 | 102FS-4d |  |  | 2009-09-07 | 2009-09-26 | 20d | 18d | 0d | 2.40 | 88/07/12 | 88/08/21 | 88/7/23 | 88/8/12 |

| ID | WBS | Task | Duration | Start | Finish | Predecessors | Baseline start | Baseline finish | Baseline duration | Total slack | Free slack | Text1 | Text2 | Text3 | START SH | FINISH SH |
| --- | --- | --- | --- | --- | --- | --- | --- | --- | --- | --- | --- | --- | --- | --- | --- | --- |
| 104 | 1.1.2.1.8 | **مرحله اول تأسیسات** | 28d | 2009-10-24 | 2009-11-20 |  | 2009-09-16 | 2009-10-13 | 28d | 18d |  | 5.00 | 88/07/12 | 88/08/21 | 88/8/2 | 88/8/29 |
| 105 | 1.1.2.1.8.1 | لوله کشی آب | 20d | 2009-10-24 | 2009-11-12 | 103FS-11d | 2009-09-16 | 2009-10-05 | 20d | 18d | 0d | 0.74 | 88/07/12 | 88/08/21 | 88/8/2 | 88/8/21 |
| 106 | 1.1.2.1.8.2 | فاضلاب و برق | 20d | 2009-10-29 | 2009-11-17 | 105SS+5d | 2009-09-21 | 2009-10-10 | 20d | 18d | 0d | 1.50 | 88/07/12 | 88/08/21 | 88/8/7 | 88/8/26 |
| 107 | 1.1.2.1.8.3 | نصب ساپورت های تأسیسات | 18d | 2009-11-03 | 2009-11-20 | 106SS+5d | 2009-09-26 | 2009-10-13 | 18d | 18d | 0d | 2.76 | 88/07/12 | 88/08/21 | 88/8/12 | 88/8/29 |
| 108 | 1.1.2.1.9 | **نمای ساختمان** | 28d | 2009-11-21 | 2009-12-18 |  | 2009-10-14 | 2009-11-10 | 28d | 18d |  | 3.00 | 88/08/22 | 88/11/06 | 88/8/30 | 88/9/27 |
| 109 | 1.1.2.1.9.1 | سنگ و آجر نما و بندکشی ها | 11d | 2009-11-21 | 2009-12-01 | 107 | 2009-10-14 | 2009-10-24 | 11d | 18d | 0d | 1.50 | 88/08/22 | 88/09/21 | 88/8/30 | 88/9/10 |
| 110 | 1.1.2.1.9.2 | سیمانکاری و رویه نما | 10d | 2009-12-02 | 2009-12-11 | 109 | 2009-10-25 | 2009-11-03 | 10d | 18d | 0d | 0.90 | 88/08/22 | 88/09/06 | 88/9/11 | 88/9/20 |
| 111 | 1.1.2.1.9.3 | نصب شیشه | 7d | 2009-12-12 | 2009-12-18 | 110 | 2009-11-04 | 2009-11-10 | 7d | 18d | 0d | 0.60 | 88/10/23 | 88/11/06 | 88/9/21 | 88/9/27 |
| 112 | 1.1.2.1.10 | **مرحله دوم نازک کاری** | 34d | 2009-11-04 | 2009-12-07 |  | 2009-09-27 | 2009-10-30 | 34d | 78d |  | 4.00 | 88/08/22 | 88/10/06 | 88/8/13 | 88/9/16 |
| 113 | 1.1.2.1.10.1 | نصب درب و پنجره ها | 16d | 2009-11-04 | 2009-11-19 | 103 | 2009-09-27 | 2009-10-12 | 16d | 78d | 0d | 0.86 | 88/08/22 | 88/09/21 | 88/8/13 | 88/8/28 |
| 114 | 1.1.2.1.10.2 | گچ و خاک و سفید کاری | 9d | 2009-11-20 | 2009-11-28 | 113 | 2009-10-13 | 2009-10-21 | 9d | 78d | 0d | 2.64 | 88/09/22 | 88/10/06 | 88/8/29 | 88/9/7 |
| 115 | 1.1.2.1.10.3 | کاشی و سرامیک سرویس ها | 9d | 2009-11-29 | 2009-12-07 | 114 | 2009-10-22 | 2009-10-30 | 9d | 78d |  | 0.50 | 88/09/22 | 88/10/06 | 88/9/8 | 88/9/16 |
| 116 | 1.1.2.1.11 | **مرحله دوم تأسیسات** | 21d | 2009-12-19 | 2010-01-08 |  | 2009-11-11 | 2009-12-01 | 21d | 18d |  | 6.50 | 88/08/25 | 88/10/12 | 88/9/28 | 88/10/18 |
| 117 | 1.1.2.1.11.1 | نصب دریچه و تجهیزات هواساز | 10d | 2009-12-19 | 2009-12-28 | 111 | 2009-11-11 | 2009-11-20 | 10d | 18d | 0d | 1.30 | 88/08/25 | 88/09/12 | 88/9/28 | 88/10/7 |
| 118 | 1.1.2.1.11.2 | نصب تابلوهای برق | 10d | 2009-12-19 | 2009-12-28 | 117SS | 2009-11-11 | 2009-11-20 | 10d | 47d | 0d | 1.30 | 88/08/25 | 88/09/16 | 88/9/28 | 88/10/7 |
| 119 | 1.1.2.1.11.3 | سیم کشی | 10d | 2009-12-19 | 2009-12-28 | 118FF | 2009-11-11 | 2009-11-20 | 10d | 47d | 0d | 0.97 | 88/09/02 | 88/09/16 | 88/9/28 | 88/10/7 |
| 120 | 1.1.2.1.11.4 | نصب کلید و پریز | 7d | 2009-12-29 | 2010-01-04 | 119 | 2009-11-21 | 2009-11-27 | 7d | 50d |  | 0.97 | 88/09/17 | 88/09/25 | 88/10/8 | 88/10/14 |
| 121 | 1.1.2.1.11.5 | روشنایی | 10d | 2009-12-29 | 2010-01-07 | 119 | 2009-11-21 | 2009-11-30 | 10d | 47d |  | 0.98 | 88/09/17 | 88/09/28 | 88/10/8 | 88/10/17 |
| 122 | 1.1.2.1.11.6 | سرویس بهداشتی | 18d | 2009-12-22 | 2010-01-08 | 117SS+3d | 2009-11-14 | 2009-12-01 | 18d | 18d |  | 0.98 | 88/09/17 | 88/10/12 | 88/10/1 | 88/10/18 |
| 123 | 1.1.2.1.12 | **رنگ آمیزی** | 28d | 2010-01-27 | 2010-02-23 | 62SS+7d | 2009-12-02 | 2009-12-29 | 28d | 0d |  | 1.50 | 88/10/07 | 88/11/06 | 88/11/7 | 88/12/4 |
| 124 | 1.1.2.1.12.1 | رنگ آمیزی ساختمان آتش نشاني | 28d | 2010-01-27 | 2010-02-23 | 122 | 2009-12-02 | 2009-12-29 | 28d | 0d |  | 1.50 |  |  | 88/11/7 | 88/12/4 |
